# DDEP_exercise_2_E15-16_2023_solution

Schedule from MS Project, 2023-04-17 to 2023-06-08, costs in €.
TEI

## Calendars

- Standard: Mon-Fri 08:00-16:00; Sat-Sun off. Exceptions (off unless hours are given): 2023-04-27 (1η αργία), 2023-04-28 (2η αργία).

## Resources

| Resource | Rate |
| --- | --- |
| Ομαδάρχης | 20 |
| Μηχανικός Ποιότητας | 15 |
| Μηχανικός Λογισμικού | 15 |
| Προγραμματιστής | 10 |

## Schedule

| ID | WBS | Task | Type | Duration | Start | Finish | Predecessors | Total slack | Free slack | Resources | Work | Cost |
| --- | --- | --- | --- | --- | --- | --- | --- | --- | --- | --- | --- | --- |
| 1 | 1 | **Καθορισμός εργασιών** |  | 2.5d | 2023-04-17 | 2023-04-19 |  | 0d |  |  | 16h | 280 |
| 2 | 1.1 | Καθορισμός καθήκοντων |  | 1d | 2023-04-17 | 2023-04-18 |  | 0d |  | Ομαδάρχης | 8h | 160 |
| 3 | 1.2 | Καθορισμός διεργασιών |  | 1d | 2023-04-18 | 2023-04-19 | 2 | 0.5d | 0d | Μηχανικός Ποιότητας | 8h | 120 |
| 4 | 2 | **Ανάλυση απαιτήσεων** |  | 4d | 2023-04-19 | 2023-04-25 |  | 0.5d |  |  | 32h | 520 |
| 5 | 2.1 | Δημιουργία Λίστας Απαιτήσεων |  | 1d | 2023-04-19 | 2023-04-20 | 3 | 0.5d | 0d | Μηχανικός Ποιότητας | 8h | 120 |
| 6 | 2.2 | Καθορισμός Ποιοτικών Χαρακτηριστικών |  | 1.5d | 2023-04-20 | 2023-04-24 | 5 | 0.5d | 0d | Ομαδάρχης; Μηχανικός Ποιότητας | 16h | 280 |
| 7 | 2.3 | Καθορισμός Μετικών |  | 1d | 2023-04-24 | 2023-04-25 | 6 | 0.5d | 0d | Μηχανικός Λογισμικού | 8h | 120 |
| 8 | 3 | **Σχεδιασμός** |  | 12d | 2023-04-25 | 2023-05-15 |  | 0.5d |  |  | 40h | 600 |
| 9 | 3.1 | Γενικός Σχεδιασμός |  | 2d | 2023-04-25 | 2023-05-02 | 7 | 0.5d | 0d | Μηχανικός Λογισμικού | 16h | 240 |
| 10 | 3.2 | Λεπτομερής Σχεδιασμός |  | 3d | 2023-05-02 | 2023-05-15 | 9 | 0.5d | 0d | Μηχανικός Λογισμικού | 24h | 360 |
| 11 | 4 | Ορόσημο | milestone | 0d | 2023-05-15 | 2023-05-15 | 10 | 18d |  |  |  |  |
| 12 | 5 | **Προγραμματισμός** |  | 15d | 2023-05-15 | 2023-06-05 |  | 0.5d |  |  | 120h | 1,200 |
| 13 | 5.1 | Κωδικκοποίηση |  | 13d | 2023-05-15 | 2023-06-01 | 10 | 0.5d | 0d | Προγραμματιστής | 104h | 1,040 |
| 14 | 5.2 | Έλεγχος Κώδικα |  | 2d | 2023-06-01 | 2023-06-05 | 13 | 3d |  | Προγραμματιστής | 16h | 160 |
| 15 | 6 | **Αναθεώρηση** |  | 5d | 2023-06-01 | 2023-06-08 |  | 0d |  |  | 40h | 640 |
| 16 | 6.1 | Έλεγχος τήρησης απαιτήσεων |  | 3d | 2023-06-01 | 2023-06-06 | 13 | 0.5d | 0d | Μηχανικός Ποιότητας | 24h | 360 |
| 17 | 6.2 | Τελικός Έλεγχος |  | 1.5d | 2023-06-06 | 2023-06-08 | 16 | 0d |  | Ομαδάρχης; Μηχανικός Ποιότητας | 16h | 280 |
